# ProgettoDegan_SAN

Schedule from MS Project, 2020-11-09 to 2021-02-03, costs in €.

## Calendars

- Standard: Mon-Fri 09:00-13:00, 14:00-18:00; Sat-Sun off.

## Resources

| Resource | Rate | Cost per use |
| --- | --- | --- |
| Analista | 62.5 | 35 |
| Analista programmatore | 50 | 35 |
| Programmatore A | 37.5 | 35 |
| Esperto WF | 70 | 45 |
| Programmatore B | 37.5 | 35 |

## Schedule

| ID | WBS | Task | Type | Duration | Start | Finish | Predecessors | Total slack | Free slack | Constraint | Resources | Work | Cost |
| --- | --- | --- | --- | --- | --- | --- | --- | --- | --- | --- | --- | --- | --- |
| 1 | 1 | **Progetto SAN** |  | 63d | 2020-11-09 | 2021-02-03 |  | 0d |  |  |  | 1143.13h | 52,333.48 |
| 2 | 1.1 | **Raccolta Requisiti** |  | 2.5d | 2020-11-09 | 2020-11-11 |  | 1.62d |  |  |  | 26.62h | 1,598.4 |
| 3 | 1.1.1 | Colloquio Primario |  | 6h | 2020-11-09 | 2020-11-09 |  | 2.38d | 0d |  | Analista [33%]; Analista programmatore | 7.98h | 470.3 |
| 4 | 1.1.2 | Colloquio Responsabile |  | 4h | 2020-11-09 | 2020-11-10 | 3 | 2.38d | 0.75d |  | Analista programmatore | 4h | 235 |
| 5 | 1.1.3 | Colloqui Ingegneria Clinica |  | 4h | 2020-11-10 | 2020-11-10 | 3 | 2.12d | 0.5d | start no earlier than 2020-11-10 | Analista [33%]; Analista programmatore | 5.32h | 329.05 |
| 6 | 1.1.4 | Colloqui Tecnici Sistema Informativo |  | 4h | 2020-11-11 | 2020-11-11 | 4, 5 | 1.62d | 0d | start no earlier than 2020-11-11 | Analista programmatore | 4h | 235 |
| 7 | 1.1.5 | Colloquio Personale Medico |  | 4h | 2020-11-11 | 2020-11-11 | 4, 5 | 1.62d | 0d | start no earlier than 2020-11-11 | Analista [33%]; Analista programmatore | 5.32h | 329.05 |
| 8 | 1.2 | ML 1 | milestone | 1d | 2020-11-11 | 2020-11-12 | 6, 7 | 1.62d |  |  |  |  |  |
| 9 | 1.3 | **Prototipazione** |  | 5.88d | 2020-11-16 | 2020-11-23 |  | 0d |  |  |  | 40.51h | 2,700.08 |
| 10 | 1.3.1 | Analisi requisiti |  | 7h | 2020-11-16 | 2020-11-16 | 8 | 0d |  | finish no earlier than 2020-11-16 | Analista [33%]; Analista programmatore | 7.31h | 441.03 |
| 11 | 1.3.2 | Progettazione architettura |  | 5d | 2020-11-17 | 2020-11-23 | 10 | 0d |  |  | Esperto WF [50%]; Analista [33%] | 33.2h | 2,259.05 |
| 12 | 1.4 | ML 2 |  | 1d | 2020-11-24 | 2020-11-24 | 11 | 0d |  |  |  |  |  |
| 13 | 1.5 | **Progettazione** |  | 18d | 2020-11-25 | 2020-12-18 |  | 0d |  |  |  | 440h | 19,600 |
| 14 | 1.5.1 | Progettazione Primario |  | 9d | 2020-11-25 | 2020-12-07 | 12 | 0d |  |  | Programmatore A; Programmatore B; Analista programmatore | 216h | 9,105 |
| 15 | 1.5.2 | Progettazione Responsabile |  | 4d | 2020-12-08 | 2020-12-11 | 14 | 1d |  |  | Programmatore B; Analista programmatore | 64h | 2,870 |
| 16 | 1.5.3 | Progettazione Ingegneria Clinica |  | 5d | 2020-12-08 | 2020-12-14 | 14 | 0d |  |  | Esperto WF [50%]; Programmatore A | 60h | 2,957.5 |
| 17 | 1.5.4 | Progettazione tecnici SI |  | 3d | 2020-12-15 | 2020-12-17 | 15, 16 | 34d |  |  | Programmatore B; Esperto WF [50%] | 36h | 1,797.5 |
| 18 | 1.5.5 | Progettazione Personale Medico |  | 4d | 2020-12-15 | 2020-12-18 | 15, 16 | 0d |  |  | Programmatore A; Analista programmatore | 64h | 2,870 |
| 19 | 1.6 | ML 3 |  | 1d | 2020-12-21 | 2020-12-21 | 18 | 0d |  |  |  |  |  |
| 20 | 1.7 | **Codifica** |  | 26d | 2020-12-22 | 2021-01-26 |  | 0d |  |  |  | 556h | 25,365 |
| 21 | 1.7.1 | Codifica Primario |  | 12d | 2020-12-22 | 2021-01-06 | 19 | 0d |  |  | Programmatore A; Analista programmatore | 192h | 8,470 |
| 22 | 1.7.2 | Codifica Responsabile |  | 8d | 2021-01-07 | 2021-01-18 | 21 | 0d |  |  | Programmatore B; Esperto WF [50%] | 96h | 4,697.5 |
| 23 | 1.7.3 | Codifica Ingegneria Clinica |  | 7d | 2021-01-07 | 2021-01-15 | 21 | 1d |  |  | Programmatore A; Analista programmatore | 112h | 4,970 |
| 24 | 1.7.4 | Codifica tecnici SI |  | 5d | 2021-01-19 | 2021-01-25 | 22, 23 | 1d |  |  | Programmatore B; Esperto WF [50%] | 60h | 2,957.5 |
| 25 | 1.7.5 | Codifica Personale Medico |  | 6d | 2021-01-19 | 2021-01-26 | 22, 23 | 0d |  |  | Programmatore A; Analista programmatore | 96h | 4,270 |
| 26 | 1.8 | ML 4 |  | 1d | 2021-01-27 | 2021-01-27 | 24, 25 | 0d |  |  |  |  |  |
| 27 | 1.9 | TEST |  | 5d | 2021-01-28 | 2021-02-03 | 26 | 0d |  |  | Programmatore A; Programmatore B | 80h | 3,070 |
